# Integration Phase

Schedule from Planner, 2010-11-15 to 2011-04-22.
Leicester Cardiovascular BRU

## Calendars

- Default: Mon-Fri 08:00-12:00, 13:00-17:00; Sat-Sun off. Exceptions (off unless hours are given): 2010-12-27 to 2010-12-31, 2011-01-03.

## Resources

| Resource |
| --- |
| The CRAs |
| Emma |
| Alison |
| Clinical DB Admin |
| Prof Samani |
| Gav and the lab staff |
| Richard Badge |
| Chris |
| Vasil |
| Jason |
| Dave |
| Jeff |
| Nick |

## Schedule

| ID | WBS | Task | Start | Finish | Predecessors | Constraint | Resources | Work |
| --- | --- | --- | --- | --- | --- | --- | --- | --- |
| 1 | 1 | **Infrastructure** | 2010-11-15 | 2011-02-25 |  |  |  | 204h |
| 2 | 1.1 | **Development environment for:** | 2010-11-15 | 2011-02-14 |  |  |  | 96h |
| 3 | 1.1.1 | caTissue | 2010-11-15 | 2010-12-02 |  |  | Dave [10%]; Jeff [5%] | 16h |
| 4 | 1.1.2 | i2b2 | 2010-11-15 | 2010-12-02 |  |  | Dave [10%]; Jeff [5%] | 16h |
| 5 | 1.1.3 | Onyx | 2010-11-15 | 2010-12-02 |  |  | Dave [10%]; Jeff [5%] | 16h |
| 6 | 1.1.4 | Questionnaire | 2010-12-02 | 2011-01-17 | 5 |  | Dave [10%]; Jeff [5%] | 32h |
| 7 | 1.1.5 | C3PR | 2011-02-01 | 2011-02-14 |  | start no earlier than 2011-02-01 | Dave [10%]; Jeff [5%]; Nick [5%] | 16h |
| 8 | 1.2 | **Establish 'test' and 'training' versions of:** | 2010-12-02 | 2011-02-17 |  |  |  | 32h |
| 9 | 1.2.1 | caTissue - on Uni system | 2010-12-02 | 2010-12-07 | 3 |  | Dave [10%]; Jeff [10%]; Nick [10%] | 8h |
| 10 | 1.2.2 | i2b2 - on UHL system | 2010-12-02 | 2010-12-07 | 4 |  | Dave [10%]; Jeff [10%]; Nick [10%] | 8h |
| 11 | 1.2.3 | Onyx - on UHL system | 2010-12-02 | 2010-12-07 | 5 |  | Dave [10%]; Jeff [10%]; Nick [10%] | 8h |
| 12 | 1.2.4 | C3PR - on UHL system | 2011-02-15 | 2011-02-17 | 7 |  | Dave [20%]; Jeff [10%]; Nick [5%] | 8h |
| 13 | 1.3 | **Backup and restore routines for:** | 2010-11-15 | 2010-11-17 |  |  |  | 24h |
| 14 | 1.3.1 | All databases | 2010-11-15 | 2010-11-17 |  |  | Dave [20%]; Jeff [10%]; Nick [5%] | 8h |
| 15 | 1.3.2 | All sub-systems | 2010-11-15 | 2010-11-17 |  |  | Dave [20%]; Jeff [10%]; Nick [5%] | 8h |
| 16 | 1.3.3 | All servers | 2010-11-15 | 2010-11-17 |  |  | Dave [20%]; Jeff [10%]; Nick [5%] | 8h |
| 17 | 1.4 | **Test Scripts for:** | 2010-11-17 | 2011-02-22 |  |  |  | 40h |
| 18 | 1.4.1 | caTissue | 2010-12-07 | 2010-12-10 | 9 |  | Dave [20%]; Jeff [10%]; Nick [5%] | 8h |
| 19 | 1.4.2 | i2b2 | 2010-12-07 | 2010-12-10 | 10 |  | Dave [20%]; Jeff [10%]; Nick [5%] | 8h |
| 20 | 1.4.3 | Onyx | 2010-12-07 | 2010-12-10 | 11 |  | Dave [20%]; Jeff [10%]; Nick [5%] | 8h |
| 21 | 1.4.4 | C3PR | 2011-02-17 | 2011-02-22 | 12 |  | Dave [20%]; Jeff [10%]; Nick [5%] | 8h |
| 22 | 1.4.5 | Database integrity | 2010-11-17 | 2010-11-22 | 14 |  | Dave [20%]; Jeff [10%]; Nick [5%] | 8h |
| 23 | 1.5 | Deploy TRAC system on university server | 2010-11-17 | 2010-11-19 | 13 |  | Dave [20%]; Jeff [5%] | 4h |
| 24 | 1.6 | System Security Review | 2011-02-22 | 2011-02-25 | 8, 17 |  | Dave [20%]; Jeff [10%]; Nick [5%] | 8h |

Notes:
- 23: Delayed for prioritisation - Dave over-committed

| ID | WBS | Task | Start | Finish | Predecessors | Constraint | Resources | Work |
| --- | --- | --- | --- | --- | --- | --- | --- | --- |
| 25 | 2 | **Onyx** | 2010-11-15 | 2011-01-28 |  |  |  | 400h |
| 26 | 2.1 | Questionnaire review | 2010-11-15 | 2010-11-30 |  |  | The CRAs [10%]; Emma [5%]; Prof Samani [5%]; Chris [5%]; Nick [10%] | 32h |
| 27 | 2.2 | Dialogue with OBiBa (& PB) re audit and validation functions | 2010-11-15 | 2010-11-18 |  |  | Chris [5%]; Jeff [10%]; Nick [10%] | 8h |
| 28 | 2.3 | Implement amendments from questionnaire review | 2011-01-18 | 2011-01-25 | 23, 6, 26 |  | The CRAs [5%]; Emma [5%]; Prof Samani [5%]; Chris [10%]; Jeff [20%]; Nick [10%] | 24h |
| 29 | 2.4 | Complete report.php chart functions | 2010-11-15 | 2010-11-26 |  |  | Vasil [50%]; Nick [5%] | 40h |
| 30 | 2.5 | Add correlations between interview and notes to report.php | 2010-11-26 | 2010-12-13 | 29 |  | Vasil [40%]; Nick [5%] | 40h |
| 31 | 2.6 | Agree protocol for questionnaire amendments | 2010-11-19 | 2010-12-06 | 23 |  | The CRAs [5%]; Emma [5%]; Chris [5%]; Vasil [5%]; Dave [5%]; Jeff [10%]; Nick [10%] | 40h |
| 32 | 2.7 | Implement agreed data integrity (audit) functionality | 2010-12-02 | 2010-12-24 | 5, 27 |  | Emma [5%]; Chris [5%]; Dave [10%]; Jeff [30%]; Nick [10%] | 80h |
| 33 | 2.8 | Implement agreed data validation functionality | 2010-12-02 | 2011-01-07 | 5, 27 |  | The CRAs [5%]; Emma [5%]; Chris [5%]; Jeff [25%]; Nick [10%] | 80h |
| 34 | 2.9 | Define and test onyx export routine | 2011-01-07 | 2011-01-19 | 33, 32, 13, 5 |  | Emma [5%]; Chris [5%]; Dave [10%]; Jeff [20%]; Nick [20%] | 40h |
| 35 | 2.10 | Implement onyx export routine | 2011-01-19 | 2011-01-28 | 34 |  | Jeff [20%]; Nick [10%] | 16h |
| 36 | 3 | **caTissue** | 2010-11-15 | 2011-02-21 |  |  |  | 312h |
| 37 | 3.1 | Upgrade to caTissue 1.2 | 2010-12-02 | 2010-12-16 | 3 | start no earlier than 2010-11-22 | Jeff [20%]; Nick [20%] | 32h |
| 38 | 3.2 | Move to briccs-1.rcs.le.ac.uk | 2010-12-16 | 2010-12-21 | 37 |  | Gav and the lab staff [10%]; Dave [10%]; Jeff [20%]; Nick [20%] | 16h |
| 39 | 3.3 | Agree SOPs for using caTissue | 2010-12-16 | 2011-01-10 | 37 |  | Alison [10%]; Gav and the lab staff [20%]; Chris [5%]; Nick [10%] | 40h |
| 40 | 3.4 | Explore API for data entry/amendment | 2010-12-16 | 2011-02-01 | 37 |  | Alison [5%]; Gav and the lab staff [10%]; Jeff [20%]; Nick [20%] | 120h |
| 41 | 3.5 | Dialogue with Kimmel Cancer Center re. i2b2 ontology | 2010-11-15 | 2010-11-22 |  |  | Gav and the lab staff [5%]; Jason [10%]; Jeff [10%]; Nick [10%] | 16h |
| 42 | 3.6 | Storage verification using 2d barcode reader -> API? | 2011-02-01 | 2011-02-21 | 37, 40 |  | Gav and the lab staff [5%]; Jeff [20%]; Nick [10%] | 40h |
| 43 | 3.7 | QC searches and reports | 2011-01-10 | 2011-01-31 | 39 |  | Alison [10%]; Gav and the lab staff [20%]; Nick [10%] | 48h |
| 44 | 4 | **i2b2** | 2010-11-15 | 2011-04-15 |  |  |  | 880h |
| 45 | 4.1 | Scope existing i2b2 ontologies | 2010-11-15 | 2010-11-22 |  |  | Prof Samani [5%]; Chris [10%]; Jason [10%]; Jeff [5%]; Nick [20%] | 24h |
| 46 | 4.2 | Scope ontologies in use within UHL data systems | 2010-11-15 | 2010-12-01 |  |  | Prof Samani [5%]; Chris [5%]; Jason [20%]; Nick [10%] | 40h |
| 47 | 4.3 | Agree strategy for ontologies in i2b2 | 2010-12-01 | 2010-12-07 | 46, 45 |  | Alison [10%]; Prof Samani [10%]; Chris [20%]; Jason [20%]; Nick [20%] | 24h |
| 48 | 4.4 | Establish test i2b2 on UHL server | 2010-12-02 | 2010-12-09 | 4 |  | Jeff [20%]; Nick [20%] | 16h |
| 49 | 4.5 | Deploy caTissue ontology in i2b2 | 2010-12-07 | 2011-01-10 | 47, 41 |  | Alison [5%]; Prof Samani [5%]; Gav and the lab staff [5%]; Chris [5%]; Jason [5%]; Jeff [20%]; Nick [10%] | 80h |
| 50 | 4.6 | Deploy agreed ontology for onyx data in i2b2 | 2010-12-07 | 2011-01-21 | 47 |  | Chris [5%]; Jason [20%]; Jeff [10%]; Nick [20%] | 120h |
| 51 | 4.7 | Deploy agreed ontology for path data in i2b2 | 2010-12-07 | 2011-01-20 | 47 |  | Alison [5%]; Prof Samani [5%]; Chris [5%]; Jason [30%]; Jeff [10%]; Nick [20%] | 160h |
| 52 | 4.8 | Deploy mapping tool for Onyx data -> i2b2 | 2011-01-21 | 2011-03-09 | 34, 50 |  | Jason [10%]; Jeff [10%]; Nick [10%] | 80h |
| 53 | 4.9 | Deploy mapping tool for path data -> i2b2 | 2011-01-20 | 2011-03-15 | 51 |  | Jason [20%]; Jeff [10%]; Nick [10%] | 120h |
| 54 | 4.10 | Implement test of onyx -> i2b2 input | 2011-03-09 | 2011-03-16 | 52 |  | Jason [10%]; Dave [10%]; Jeff [10%]; Nick [10%] | 16h |
| 55 | 4.11 | Implement test of caTissue -> i2b2 input | 2011-01-10 | 2011-01-24 | 49 |  | Alison [5%]; Prof Samani [5%]; Gav and the lab staff [5%]; Chris [5%]; Vasil [5%]; Dave [5%]; Jeff [10%]; Nick [10%] | 40h |
| 56 | 4.12 | Implement test of path -> i2b2 input | 2011-03-15 | 2011-04-01 | 53 |  | Chris [5%]; Vasil [10%]; Jason [20%]; Jeff [20%]; Nick [20%] | 80h |
| 57 | 4.13 | Implement onyx -> i2b2 input live version | 2011-03-16 | 2011-03-23 | 54 |  | Vasil [10%]; Jason [10%]; Jeff [20%]; Nick [20%] | 24h |
| 58 | 4.14 | Implement caTissue -> i2b2 input live version | 2011-01-24 | 2011-01-28 | 55 |  | Alison [5%]; Gav and the lab staff [5%]; Jeff [20%]; Nick [20%] | 16h |
| 59 | 4.15 | Implement path -> i2b2 live version | 2011-04-01 | 2011-04-15 | 56 |  | Jason [10%]; Jeff [20%]; Nick [20%] | 40h |

Notes:
- 32: Might be a much higher demand for Jeff / Dave if OBiBa are unable to implement.

| ID | WBS | Task | Start | Finish | Predecessors | Constraint | Resources | Work |
| --- | --- | --- | --- | --- | --- | --- | --- | --- |
| 60 | 5 | **Registry** | 2010-11-15 | 2011-04-21 |  |  |  | 872h |
| 61 | 5.1 | Define BRICCS desired outputs from registry | 2010-11-15 | 2010-11-24 |  |  | Clinical DB Admin [5%]; Prof Samani [5%]; Chris [10%]; Jason [10%]; Nick [10%] | 24h |
| 62 | 5.2 | Assess PATS, Clinical Workstation and eclipse, etc. | 2010-11-24 | 2011-01-06 | 61 |  | Clinical DB Admin [20%]; Prof Samani [5%]; Chris [20%]; Jason [20%]; Jeff [10%]; Nick [10%] | 168h |
| 63 | 5.3 | Scoping clinical data informatics systems | 2010-11-15 | 2010-12-17 |  |  | Clinical DB Admin [10%]; Prof Samani [0%]; Chris [30%] | 80h |
| 64 | 5.4 | Assess existing PATS as a data source for i2b2 | 2011-01-06 | 2011-04-21 | 62 |  | Clinical DB Admin [20%]; Chris [20%]; Jason [20%]; Jeff [20%]; Nick [20%] | 600h |
| 65 | 6 | **Management reporting** | 2010-11-29 | 2011-04-22 |  |  |  | 240h |
| 66 | 6.1 | Adapt excel management report to evaluate OP recruitment | 2010-11-29 | 2011-01-21 |  | start no earlier than 2010-11-29 | Emma [10%]; Chris [10%]; Nick [10%] | 80h |
| 67 | 6.2 | **Implement C3PR** | 2011-02-25 | 2011-04-22 |  |  |  | 160h |
| 68 | 6.2.1 | Test C3PR | 2011-02-25 | 2011-03-11 | 1 |  | Jeff [20%]; Nick [30%] | 40h |
| 69 | 6.2.2 | Deploy C3PR | 2011-03-11 | 2011-03-30 | 68 |  | Jeff [20%]; Nick [20%] | 40h |
| 70 | 6.2.3 | Configure C3PR | 2011-03-30 | 2011-04-13 | 69 |  | The CRAs [10%]; Emma [10%]; Chris [5%]; Jeff [5%]; Nick [20%] | 40h |
| 71 | 6.2.4 | Train CRAs etc in use of C3PR | 2011-04-13 | 2011-04-22 | 7, 70 |  | The CRAs [20%]; Emma [20%]; Chris [10%]; Nick [20%] | 40h |
| 72 | 7 | **Genomics data** | 2010-11-15 | 2011-03-17 |  |  |  | 240h |
| 73 | 7.1 | Scope options | 2010-11-15 | 2011-02-10 |  |  | Alison [5%]; Prof Samani [0%]; Gav and the lab staff [5%]; Richard Badge [5%]; Chris [5%]; Jason [5%]; Jeff [5%]; Nick [5%] | 160h |
| 74 | 7.2 | Deploy initial test of chosen system | 2011-02-10 | 2011-03-17 | 73 |  | Alison [5%]; Gav and the lab staff [5%]; Jeff [20%]; Nick [10%] | 80h |

Notes:
- 73: Including i2b2 genomics cell, GALAXY, GenoByte
